Schedule from MS Project, 2008-03-03 to 2008-09-10, status date 2008-09-10, costs in $, A marks actual dates.

## Calendars

- Standard: Mon-Fri 08:00-12:00, 13:00-17:00; Sat-Sun off.

## Resources

| Resource | Rate |
| --- | --- |
| Project Manager | 100 |
| Business Analyst | 80 |
| Architect | 120 |
| Developer - 1 | 50 |
| Technical Leader | 70 |
| Tester | 50 |
| User | 120 |
| Developer - 2 | 50 |
| Developer - 3 | 50 |

## Schedule

| ID | WBS | Task | Duration | Start | Finish | Predecessors | Complete | Baseline start | Baseline finish | Baseline duration | Constraint | Resources | Work | Actual work | Cost | Baseline cost | Actual cost |
| --- | --- | --- | --- | --- | --- | --- | --- | --- | --- | --- | --- | --- | --- | --- | --- | --- | --- |
| 1 | 1 | **PM Software** | 138d | 2008-03-03 A | 2008-09-10 A |  | 100% | 2008-03-03 | 2008-09-04 | 133.89d |  |  | 2731h | 2731h | 192,890 | 205,130 | 192,890 |
| 2 | 1.1 | Architect to Present Architecture to the Client | 2d | 2008-04-07 A | 2008-04-08 A |  | 100% | 2008-04-07 | 2008-04-08 | 2d | start no earlier than 2008-04-07 | Architect | 16h | 16h | 1,920 | 1,920 | 1,920 |
| 3 | 1.2 | Political Emergency | 1d | 2008-04-09 A | 2008-04-09 A |  | 100% | 2008-04-09 | 2008-04-09 | 1d | start no earlier than 2008-04-09 |  |  |  |  |  |  |
| 4 | 1.3 | **Weekly Team Meeting** | 40.12d | 2008-03-03 A | 2008-04-28 A |  | 100% | 2008-03-03 | 2008-04-28 | 40.12d |  |  | 54h | 54h | 4,230 | 4,230 | 4,230 |
| 5 | 1.3.1 | Weekly Team Meeting 1 | 1h | 2008-03-03 A | 2008-03-03 A |  | 100% | 2008-03-03 | 2008-03-03 | 1h | start no earlier than 2008-03-03 | Project Manager; Business Analyst; Architect; Developer - 1; Technical Leader; Tester | 6h | 6h | 470 | 470 | 470 |
| 6 | 1.3.2 | Weekly Team Meeting 2 | 1h | 2008-03-10 A | 2008-03-10 A |  | 100% | 2008-03-10 | 2008-03-10 | 1h | start no earlier than 2008-03-10 | Project Manager; Business Analyst; Architect; Developer - 1; Technical Leader; Tester | 6h | 6h | 470 | 470 | 470 |
| 7 | 1.3.3 | Weekly Team Meeting 3 | 1h | 2008-03-17 A | 2008-03-17 A |  | 100% | 2008-03-17 | 2008-03-17 | 1h | start no earlier than 2008-03-17 | Project Manager; Business Analyst; Architect; Developer - 1; Technical Leader; Tester | 6h | 6h | 470 | 470 | 470 |
| 8 | 1.3.4 | Weekly Team Meeting 4 | 1h | 2008-03-24 A | 2008-03-24 A |  | 100% | 2008-03-24 | 2008-03-24 | 1h | start no earlier than 2008-03-24 | Project Manager; Business Analyst; Architect; Developer - 1; Technical Leader; Tester | 6h | 6h | 470 | 470 | 470 |
| 9 | 1.3.5 | Weekly Team Meeting 5 | 1h | 2008-03-31 A | 2008-03-31 A |  | 100% | 2008-03-31 | 2008-03-31 | 1h | start no earlier than 2008-03-31 | Project Manager; Business Analyst; Architect; Developer - 1; Technical Leader; Tester | 6h | 6h | 470 | 470 | 470 |
| 10 | 1.3.6 | Weekly Team Meeting 6 | 1h | 2008-04-07 A | 2008-04-07 A |  | 100% | 2008-04-07 | 2008-04-07 | 1h | start no earlier than 2008-04-07 | Project Manager; Business Analyst; Architect; Developer - 1; Technical Leader; Tester | 6h | 6h | 470 | 470 | 470 |
| 11 | 1.3.7 | Weekly Team Meeting 7 | 1h | 2008-04-14 A | 2008-04-14 A |  | 100% | 2008-04-14 | 2008-04-14 | 1h | start no earlier than 2008-04-14 | Project Manager; Business Analyst; Architect; Developer - 1; Technical Leader; Tester | 6h | 6h | 470 | 470 | 470 |
| 12 | 1.3.8 | Weekly Team Meeting 8 | 1h | 2008-04-21 A | 2008-04-21 A |  | 100% | 2008-04-21 | 2008-04-21 | 1h | start no earlier than 2008-04-21 | Project Manager; Business Analyst; Architect; Developer - 1; Technical Leader; Tester | 6h | 6h | 470 | 470 | 470 |
| 13 | 1.3.9 | Weekly Team Meeting 9 | 1h | 2008-04-28 A | 2008-04-28 A |  | 100% | 2008-04-28 | 2008-04-28 | 1h | start no earlier than 2008-04-28 | Project Manager; Business Analyst; Architect; Developer - 1; Technical Leader; Tester | 6h | 6h | 470 | 470 | 470 |
| 14 | 1.4 | **Weekly Status Meeting** | 40.12d | 2008-03-04 A | 2008-04-29 A |  | 100% | 2008-03-04 | 2008-04-29 | 40.12d |  |  | 18h | 18h | 1,980 | 1,980 | 1,980 |
| 15 | 1.4.1 | Weekly Status Meeting 1 | 1h | 2008-03-04 A | 2008-03-04 A |  | 100% | 2008-03-04 | 2008-03-04 | 1h | start no earlier than 2008-03-04 | Project Manager; User | 2h | 2h | 220 | 220 | 220 |
| 16 | 1.4.2 | Weekly Status Meeting 2 | 1h | 2008-03-11 A | 2008-03-11 A |  | 100% | 2008-03-11 | 2008-03-11 | 1h | start no earlier than 2008-03-11 | Project Manager; User | 2h | 2h | 220 | 220 | 220 |
| 17 | 1.4.3 | Weekly Status Meeting 3 | 1h | 2008-03-18 A | 2008-03-18 A |  | 100% | 2008-03-18 | 2008-03-18 | 1h | start no earlier than 2008-03-18 | Project Manager; User | 2h | 2h | 220 | 220 | 220 |
| 18 | 1.4.4 | Weekly Status Meeting 4 | 1h | 2008-03-25 A | 2008-03-25 A |  | 100% | 2008-03-25 | 2008-03-25 | 1h | start no earlier than 2008-03-25 | Project Manager; User | 2h | 2h | 220 | 220 | 220 |
| 19 | 1.4.5 | Weekly Status Meeting 5 | 1h | 2008-04-01 A | 2008-04-01 A |  | 100% | 2008-04-01 | 2008-04-01 | 1h | start no earlier than 2008-04-01 | Project Manager; User | 2h | 2h | 220 | 220 | 220 |
| 20 | 1.4.6 | Weekly Status Meeting 6 | 1h | 2008-04-08 A | 2008-04-08 A |  | 100% | 2008-04-08 | 2008-04-08 | 1h | start no earlier than 2008-04-08 | Project Manager; User | 2h | 2h | 220 | 220 | 220 |
| 21 | 1.4.7 | Weekly Status Meeting 7 | 1h | 2008-04-15 A | 2008-04-15 A |  | 100% | 2008-04-15 | 2008-04-15 | 1h | start no earlier than 2008-04-15 | Project Manager; User | 2h | 2h | 220 | 220 | 220 |
| 22 | 1.4.8 | Weekly Status Meeting 8 | 1h | 2008-04-22 A | 2008-04-22 A |  | 100% | 2008-04-22 | 2008-04-22 | 1h | start no earlier than 2008-04-22 | Project Manager; User | 2h | 2h | 220 | 220 | 220 |
| 23 | 1.4.9 | Weekly Status Meeting 9 | 1h | 2008-04-29 A | 2008-04-29 A |  | 100% | 2008-04-29 | 2008-04-29 | 1h | start no earlier than 2008-04-29 | Project Manager; User | 2h | 2h | 220 | 220 | 220 |
| 24 | 1.5 | **Requirements** | 15.12d | 2008-03-03 A | 2008-03-24 A |  | 100% | 2008-03-03 | 2008-03-21 | 14.5d |  |  | 118h | 118h | 9,960 | 9,560 | 9,960 |
| 25 | 1.5.1 | Prepare Requirements | 10.62d | 2008-03-03 A | 2008-03-17 A |  | 100% | 2008-03-03 | 2008-03-17 | 10d |  | Business Analyst | 85h | 85h | 6,800 | 6,400 | 6,800 |
| 26 | 1.5.2 | Review Requirements | 1d | 2008-03-18 A | 2008-03-19 A | 25 | 100% | 2008-03-17 | 2008-03-18 | 1d |  | Project Manager | 8h | 8h | 800 | 800 | 800 |
| 27 | 1.5.3 | Incorporate Review comments | 1d | 2008-03-19 A | 2008-03-20 A | 26 | 100% | 2008-03-18 | 2008-03-19 | 1d |  | Business Analyst | 8h | 8h | 640 | 640 | 640 |
| 28 | 1.5.4 | User Review | 1d | 2008-03-20 A | 2008-03-21 A | 27 | 100% | 2008-03-19 | 2008-03-20 | 1d |  | User | 8h | 8h | 960 | 960 | 960 |
| 29 | 1.5.5 | User Review Comments Incorporation | 1d | 2008-03-21 A | 2008-03-24 A | 28 | 100% | 2008-03-20 | 2008-03-21 | 1d |  | Business Analyst | 8h | 8h | 640 | 640 | 640 |
| 30 | 1.5.6 | Final Approval | 0.12d | 2008-03-24 A | 2008-03-24 A | 29 | 100% | 2008-03-21 | 2008-03-21 | 0.12d |  | User | 1h | 1h | 120 | 120 | 120 |

| ID | WBS | Task | Duration | Start | Finish | Predecessors | Complete | Baseline start | Baseline finish | Baseline duration | Resources | Work | Actual work | Cost | Baseline cost | Actual cost |
| --- | --- | --- | --- | --- | --- | --- | --- | --- | --- | --- | --- | --- | --- | --- | --- | --- |
| 31 | 1.6 | **High Level Design** | 17d | 2008-03-24 A | 2008-04-16 A | 24 | 100% | 2008-03-21 | 2008-04-15 | 16.62d |  | 121h | 121h | 9,720 | 8,760 | 9,720 |
| 32 | 1.6.1 | Prepare High Level Design | 10d | 2008-03-24 A | 2008-04-07 A |  | 100% | 2008-03-21 | 2008-04-04 | 10d | Technical Leader | 80h | 80h | 5,600 | 5,600 | 5,600 |
| 33 | 1.6.2 | Review HLD | 1d | 2008-04-09 A | 2008-04-09 A | 32 | 100% | 2008-04-09 | 2008-04-09 | 1d | Architect | 8h | 8h | 960 | 960 | 960 |
| 34 | 1.6.3 | Incorporate Review Comments | 1d | 2008-04-10 A | 2008-04-10 A | 33 | 100% | 2008-04-10 | 2008-04-10 | 1d | Technical Leader | 8h | 8h | 560 | 560 | 560 |
| 35 | 1.6.4 | User Review | 2d | 2008-04-11 A | 2008-04-14 A | 34 | 100% | 2008-04-11 | 2008-04-11 | 1d | User | 16h | 16h | 1,920 | 960 | 1,920 |
| 36 | 1.6.5 | User Review Comments Incorporation | 1d | 2008-04-15 A | 2008-04-16 A | 35 | 100% | 2008-04-14 | 2008-04-15 | 1d | Technical Leader | 8h | 8h | 560 | 560 | 560 |
| 37 | 1.6.6 | Final Approval | 0.12d | 2008-04-16 A | 2008-04-16 A | 36 | 100% | 2008-04-15 | 2008-04-15 | 0.12d | User | 1h | 1h | 120 | 120 | 120 |
| 38 | 1.7 | **Planning Module** | 36.5d | 2008-04-16 A | 2008-06-05 A | 31 | 100% | 2008-04-15 | 2008-06-12 | 42.5d |  | 284h | 284h | 15,000 | 16,600 | 15,000 |
| 39 | 1.7.1 | Prepare Low Level Design | 3d | 2008-04-16 A | 2008-04-21 A |  | 100% | 2008-04-15 | 2008-04-22 | 5d | Developer - 1 | 24h | 24h | 1,200 | 2,000 | 1,200 |
| 40 | 1.7.2 | LLD Review | 1d | 2008-04-22 A | 2008-04-23 A | 39 | 100% | 2008-04-23 | 2008-04-24 | 1d | Technical Leader | 8h | 8h | 560 | 560 | 560 |
| 41 | 1.7.3 | LLD Review Comments Incorporation | 1d | 2008-04-23 A | 2008-04-24 A | 40 | 100% | 2008-04-24 | 2008-04-25 | 1d | Developer - 1 | 8h | 8h | 400 | 400 | 400 |
| 42 | 1.7.4 | Unit Test Plan Preparation | 3d | 2008-04-24 A | 2008-04-29 A | 41 | 100% | 2008-04-25 | 2008-05-02 | 5d | Developer - 1 | 24h | 24h | 1,200 | 2,000 | 1,200 |
| 43 | 1.7.5 | UTP Review | 1d | 2008-04-29 A | 2008-04-30 A | 42 | 100% | 2008-05-02 | 2008-05-05 | 1d | Technical Leader | 8h | 8h | 560 | 560 | 560 |
| 44 | 1.7.6 | UTP Review Comments Incorporation | 1d | 2008-04-30 A | 2008-05-01 A | 43 | 100% | 2008-05-05 | 2008-05-06 | 1d | Developer - 1 | 8h | 8h | 400 | 400 | 400 |
| 45 | 1.7.7 | Coding | 15d | 2008-05-01 A | 2008-05-22 A | 44 | 100% | 2008-05-06 | 2008-05-27 | 15d | Developer - 1 | 120h | 120h | 6,000 | 6,000 | 6,000 |
| 46 | 1.7.8 | Unit Testing | 5d | 2008-05-22 A | 2008-05-29 A | 45 | 100% | 2008-05-27 | 2008-06-03 | 5d | Developer - 1 | 40h | 40h | 2,000 | 2,000 | 2,000 |
| 47 | 1.7.9 | Code Review | 3d | 2008-05-29 A | 2008-06-03 A | 46 | 100% | 2008-06-05 | 2008-06-10 | 3d | Technical Leader | 24h | 24h | 1,680 | 1,680 | 1,680 |
| 48 | 1.7.10 | Code Review Comments Incorporation | 2d | 2008-06-03 A | 2008-06-05 A | 47 | 100% | 2008-06-10 | 2008-06-12 | 2d | Developer - 1 | 16h | 16h | 800 | 800 | 800 |
| 49 | 1.7.11 | Move to Integration Testing | 0.5d | 2008-06-05 A | 2008-06-05 A | 48 | 100% | 2008-06-12 | 2008-06-12 | 0.5d | Developer - 1 | 4h | 4h | 200 | 200 | 200 |
| 50 | 1.8 | **Schedule Module** | 59.38d | 2008-04-16 A | 2008-07-08 A | 31 | 100% | 2008-04-15 | 2008-07-03 | 57.38d |  | 612h | 612h | 32,200 | 31,400 | 32,200 |
| 51 | 1.8.1 | Prepare Low Level Design | 10d | 2008-04-16 A | 2008-04-30 A |  | 100% | 2008-04-15 | 2008-04-29 | 10d | Developer - 2 | 80h | 80h | 4,000 | 4,000 | 4,000 |
| 52 | 1.8.2 | LLD Review | 2d | 2008-04-30 A | 2008-05-02 A | 51 | 100% | 2008-04-29 | 2008-05-01 | 2d | Technical Leader | 16h | 16h | 1,120 | 1,120 | 1,120 |
| 53 | 1.8.3 | LLD Review Comments Incorporation | 1d | 2008-05-02 A | 2008-05-05 A | 52 | 100% | 2008-05-01 | 2008-05-02 | 1d | Developer - 2 | 8h | 8h | 400 | 400 | 400 |
| 54 | 1.8.4 | Unit Test Plan Preparation | 10d | 2008-05-05 A | 2008-05-19 A | 53 | 100% | 2008-05-02 | 2008-05-16 | 10d | Developer - 2 | 80h | 80h | 4,000 | 4,000 | 4,000 |
| 55 | 1.8.5 | UTP Review | 2d | 2008-05-19 A | 2008-05-21 A | 54 | 100% | 2008-05-16 | 2008-05-20 | 2d | Technical Leader | 16h | 16h | 1,120 | 1,120 | 1,120 |
| 56 | 1.8.6 | UTP Review Comments Incorporation | 1d | 2008-05-21 A | 2008-05-22 A | 55 | 100% | 2008-05-20 | 2008-05-21 | 1d | Developer - 2 | 8h | 8h | 400 | 400 | 400 |
| 57 | 1.8.7 | Coding | 11.25d | 2008-05-22 A | 2008-06-06 A | 56 | 100% | 2008-05-21 | 2008-06-05 | 11.25d | Developer - 2 | 90h | 90h | 4,500 | 4,500 | 4,500 |
| 58 | 1.8.8 | Coding - 2 | 9.38d | 2008-06-04 A | 2008-06-20 A | 56 | 100% | 2008-06-03 | 2008-06-19 | 9.38d | Developer - 1 | 75h | 75h | 3,750 | 3,750 | 3,750 |
| 59 | 1.8.9 | Coding - 3 | 9.38d | 2008-06-03 A | 2008-06-19 A | 56 | 100% | 2008-06-02 | 2008-06-18 | 9.38d | Developer - 3 | 75h | 75h | 3,750 | 3,750 | 3,750 |
| 60 | 1.8.10 | Unit Testing | 4d | 2008-06-06 A | 2008-06-12 A | 57 | 100% | 2008-06-05 | 2008-06-11 | 4d | Developer - 2 | 32h | 32h | 1,600 | 1,600 | 1,600 |
| 61 | 1.8.11 | Unit Testing - 2 | 3d | 2008-06-20 A | 2008-06-25 A | 58 | 100% | 2008-06-19 | 2008-06-24 | 3d | Developer - 1 | 24h | 24h | 1,200 | 1,200 | 1,200 |
| 62 | 1.8.12 | Unit Testing - 3 | 5d | 2008-06-19 A | 2008-06-26 A | 59 | 100% | 2008-06-18 | 2008-06-23 | 3d | Developer - 3 | 40h | 40h | 2,000 | 1,200 | 2,000 |
| 63 | 1.8.13 | Code Review | 6d | 2008-06-26 A | 2008-07-04 A | 62 | 100% | 2008-06-23 | 2008-07-01 | 6d | Technical Leader | 48h | 48h | 3,360 | 3,360 | 3,360 |
| 64 | 1.8.14 | Code Review Comments Incorporation | 2d | 2008-07-04 A | 2008-07-08 A | 63 | 100% | 2008-07-01 | 2008-07-03 | 2d | Developer - 2 | 16h | 16h | 800 | 800 | 800 |
| 65 | 1.8.15 | Move to Integration Testing | 0.5d | 2008-07-08 A | 2008-07-08 A | 64 | 100% | 2008-07-03 | 2008-07-03 | 0.5d | Developer - 2 | 4h | 4h | 200 | 200 | 200 |

| ID | WBS | Task | Duration | Start | Finish | Predecessors | Complete | Baseline start | Baseline finish | Baseline duration | Resources | Work | Actual work | Cost | Baseline cost | Actual cost |
| --- | --- | --- | --- | --- | --- | --- | --- | --- | --- | --- | --- | --- | --- | --- | --- | --- |
| 66 | 1.9 | **Administration Module** | 37.5d | 2008-04-16 A | 2008-06-06 A | 31 | 100% | 2008-04-15 | 2008-06-09 | 39.5d |  | 300h | 300h | 15,800 | 16,600 | 15,800 |
| 67 | 1.9.1 | Prepare Low Level Design | 4d | 2008-04-16 A | 2008-04-22 A |  | 100% | 2008-04-15 | 2008-04-22 | 5d | Developer - 3 | 32h | 32h | 1,600 | 2,000 | 1,600 |
| 68 | 1.9.2 | LLD Review | 1d | 2008-04-22 A | 2008-04-23 A | 67 | 100% | 2008-04-22 | 2008-04-23 | 1d | Technical Leader | 8h | 8h | 560 | 560 | 560 |
| 69 | 1.9.3 | LLD Review Comments Incorporation | 1d | 2008-04-23 A | 2008-04-24 A | 68 | 100% | 2008-04-23 | 2008-04-24 | 1d | Developer - 3 | 8h | 8h | 400 | 400 | 400 |
| 70 | 1.9.4 | Unit Test Plan Preparation | 4d | 2008-04-24 A | 2008-04-30 A | 69 | 100% | 2008-04-24 | 2008-05-01 | 5d | Developer - 3 | 32h | 32h | 1,600 | 2,000 | 1,600 |
| 71 | 1.9.5 | UTP Review | 1d | 2008-04-30 A | 2008-05-01 A | 70 | 100% | 2008-05-01 | 2008-05-02 | 1d | Technical Leader | 8h | 8h | 560 | 560 | 560 |
| 72 | 1.9.6 | UTP Review Comments Incorporation | 1d | 2008-05-01 A | 2008-05-02 A | 71 | 100% | 2008-05-02 | 2008-05-05 | 1d | Developer - 3 | 8h | 8h | 400 | 400 | 400 |
| 73 | 1.9.7 | Coding | 15d | 2008-05-02 A | 2008-05-23 A | 72 | 100% | 2008-05-05 | 2008-05-26 | 15d | Developer - 3 | 120h | 120h | 6,000 | 6,000 | 6,000 |
| 74 | 1.9.8 | Unit Testing | 5d | 2008-05-23 A | 2008-05-30 A | 73 | 100% | 2008-05-26 | 2008-06-02 | 5d | Developer - 3 | 40h | 40h | 2,000 | 2,000 | 2,000 |
| 75 | 1.9.9 | Code Review | 3d | 2008-05-30 A | 2008-06-04 A | 74 | 100% | 2008-06-02 | 2008-06-05 | 3d | Technical Leader | 24h | 24h | 1,680 | 1,680 | 1,680 |
| 76 | 1.9.10 | Code Review Comments Incorporation | 2d | 2008-06-04 A | 2008-06-06 A | 75 | 100% | 2008-06-05 | 2008-06-09 | 2d | Developer - 3 | 16h | 16h | 800 | 800 | 800 |
| 77 | 1.9.11 | Move to Integration Testing | 0.5d | 2008-06-06 A | 2008-06-06 A | 76 | 100% | 2008-06-09 | 2008-06-09 | 0.5d | Developer - 3 | 4h | 4h | 200 | 200 | 200 |
| 78 | 1.10 | **Integration Testing** | 93.88d | 2008-03-03 A | 2008-07-10 A |  | 100% | 2008-03-03 | 2008-07-07 | 90.5d |  | 432h | 432h | 22,320 | 22,320 | 22,320 |
| 79 | 1.10.1 | Integration Test Plan Preparation | 2d | 2008-03-03 A | 2008-03-05 A |  | 100% | 2008-03-03 | 2008-03-05 | 2d | Tester [500%] | 80h | 80h | 4,000 | 4,000 | 4,000 |
| 80 | 1.10.2 | Integration Test Plan Review | 2d | 2008-03-17 A | 2008-03-20 A | 79 | 100% | 2008-03-17 | 2008-03-20 | 2d | Business Analyst | 16h | 16h | 1,280 | 1,280 | 1,280 |
| 81 | 1.10.3 | Integration Test Plan Review Comments Incorporation | 0.2d | 2008-03-20 A | 2008-03-20 A | 80 | 100% | 2008-03-20 | 2008-03-20 | 0.2d | Tester [500%] | 8h | 8h | 400 | 400 | 400 |
| 82 | 1.10.4 | Integration Testing - Planning Module | 2d | 2008-06-05 A | 2008-06-09 A | 81, 38 | 100% | 2008-06-12 | 2008-06-16 | 2d | Tester [500%] | 80h | 80h | 4,000 | 4,000 | 4,000 |
| 83 | 1.10.5 | Integration Testing - Schedule Module | 2d | 2008-07-08 A | 2008-07-10 A | 81, 50 | 100% | 2008-07-03 | 2008-07-07 | 2d | Tester [500%] | 80h | 80h | 4,000 | 4,000 | 4,000 |
| 84 | 1.10.6 | Integration Testing - Administration Module | 2d | 2008-06-06 A | 2008-06-10 A | 81, 66 | 100% | 2008-06-09 | 2008-06-11 | 2d | Tester [500%] | 80h | 80h | 4,000 | 4,000 | 4,000 |
| 85 | 1.10.7 | Integration Test Bug Fixing | 3.33d | 2008-06-23 A | 2008-06-26 A | 84 | 100% | 2008-06-24 | 2008-06-27 | 3.33d | Developer - 1; Developer - 2; Developer - 3 | 80h | 80h | 4,000 | 4,000 | 4,000 |
| 86 | 1.10.8 | Integration Test Sign Off | 1d | 2008-07-10 A | 2008-07-10 A | 85 | 100% | 2008-06-27 | 2008-06-30 | 1d | Business Analyst | 8h | 8h | 640 | 640 | 640 |
| 87 | 1.11 | **User Acceptance Testing** | 10.4d | 2008-07-11 A | 2008-07-25 A | 78 | 100% | 2008-07-07 | 2008-07-22 | 10.4d |  | 432h | 432h | 45,600 | 45,600 | 45,600 |
| 88 | 1.11.1 | User Acceptance Test Plan Preparation | 2d | 2008-07-11 A | 2008-07-14 A |  | 100% | 2008-07-07 | 2008-07-09 | 2d | User [500%] | 80h | 80h | 9,600 | 9,600 | 9,600 |
| 89 | 1.11.2 | User Acceptance Test Plan Review | 2d | 2008-07-15 A | 2008-07-16 A | 88 | 100% | 2008-07-09 | 2008-07-11 | 2d | Business Analyst | 16h | 16h | 1,280 | 1,280 | 1,280 |
| 90 | 1.11.3 | User Acceptance Test Plan Review Comments Incorporation | 0.2d | 2008-07-17 A | 2008-07-17 A | 89 | 100% | 2008-07-11 | 2008-07-11 | 0.2d | User [500%] | 8h | 8h | 960 | 960 | 960 |
| 91 | 1.11.4 | UAT - Planning Module | 2d | 2008-07-23 A | 2008-07-25 A | 90 | 100% | 2008-07-17 | 2008-07-22 | 2d | User [500%] | 80h | 80h | 9,600 | 9,600 | 9,600 |
| 92 | 1.11.5 | UAT - Schedule Module | 2d | 2008-07-21 A | 2008-07-23 A | 90 | 100% | 2008-07-15 | 2008-07-17 | 2d | User [500%] | 80h | 80h | 9,600 | 9,600 | 9,600 |
| 93 | 1.11.6 | UAT - Administration Module | 2d | 2008-07-17 A | 2008-07-21 A | 90 | 100% | 2008-07-11 | 2008-07-15 | 2d | User [500%] | 80h | 80h | 9,600 | 9,600 | 9,600 |
| 94 | 1.11.7 | User Acceptance Test Bug Fixing | 3.33d | 2008-07-21 A | 2008-07-24 A | 93 | 100% | 2008-07-15 | 2008-07-21 | 3.33d | Developer - 1; Developer - 2; Developer - 3 | 80h | 80h | 4,000 | 4,000 | 4,000 |
| 95 | 1.11.8 | User Acceptance Test Sign Off | 0.2d | 2008-07-24 A | 2008-07-24 A | 94 | 100% | 2008-07-21 | 2008-07-21 | 0.2d | User [500%] | 8h | 8h | 960 | 960 | 960 |

| ID | WBS | Task | Type | Duration | Start | Finish | Predecessors | Complete | Baseline start | Baseline finish | Baseline duration | Resources | Work | Actual work | Cost | Baseline cost | Actual cost |
| --- | --- | --- | --- | --- | --- | --- | --- | --- | --- | --- | --- | --- | --- | --- | --- | --- | --- |
| 96 | 1.12 | **Pilot Implementation** |  | 14.47d | 2008-07-25 A | 2008-08-14 A | 87 | 100% | 2008-07-22 | 2008-08-06 | 11.87d |  | 256h | 256h | 26,240 | 26,240 | 26,240 |
| 97 | 1.12.1 | Pilot Planning |  | 3d | 2008-07-25 A | 2008-07-30 A |  | 100% | 2008-07-22 | 2008-07-25 | 3d | Project Manager | 24h | 24h | 2,400 | 2,400 | 2,400 |
| 98 | 1.12.2 | Pilot Deployment |  | 3d | 2008-08-04 A | 2008-08-06 A | 97 | 100% | 2008-07-25 | 2008-07-30 | 3d | Technical Leader | 24h | 24h | 1,680 | 1,680 | 1,680 |
| 99 | 1.12.3 | Pilot Run |  | 4d | 2008-08-07 A | 2008-08-12 A | 98 | 100% | 2008-07-30 | 2008-08-05 | 4d | User [500%] | 160h | 160h | 19,200 | 19,200 | 19,200 |
| 100 | 1.12.4 | Pilot Run Bug Fixing |  | 1.67d | 2008-08-13 A | 2008-08-14 A | 99 | 100% | 2008-08-05 | 2008-08-06 | 1.67d | Developer - 1; Developer - 2; Developer - 3 | 40h | 40h | 2,000 | 2,000 | 2,000 |
| 101 | 1.12.5 | Pilot Run Sign Off |  | 0.2d | 2008-08-14 A | 2008-08-14 A | 100 | 100% | 2008-08-06 | 2008-08-06 | 0.2d | User [500%] | 8h | 8h | 960 | 960 | 960 |
| 102 | 1.13 | **Production Rollout** |  | 19.13d | 2008-08-14 A | 2008-09-10 A | 96 | 100% | 2008-08-06 | 2008-08-21 | 11d |  | 88h | 88h | 7,920 | 7,920 | 7,920 |
| 103 | 1.13.1 | Production Planning |  | 3d | 2008-08-14 A | 2008-08-19 A |  | 100% | 2008-08-06 | 2008-08-11 | 3d | Project Manager | 24h | 24h | 2,400 | 2,400 | 2,400 |
| 104 | 1.13.2 | Production Deployment |  | 3d | 2008-08-19 A | 2008-08-22 A | 103 | 100% | 2008-08-11 | 2008-08-14 | 3d | Technical Leader | 24h | 24h | 1,680 | 1,680 | 1,680 |
| 105 | 1.13.3 | Production Test |  | 3d | 2008-08-25 A | 2008-08-27 A | 104 | 100% | 2008-08-14 | 2008-08-19 | 3d | Business Analyst | 24h | 24h | 1,920 | 1,920 | 1,920 |
| 106 | 1.13.4 | Production Sign Off |  | 1d | 2008-09-09 A | 2008-09-09 A | 105 | 100% | 2008-08-19 | 2008-08-20 | 1d | User | 8h | 8h | 960 | 960 | 960 |
| 107 | 1.13.5 | Application Live |  | 1d | 2008-09-10 A | 2008-09-10 A | 106 | 100% | 2008-08-20 | 2008-08-21 | 1d | User | 8h | 8h | 960 | 960 | 960 |
| 108 | 1.14 | Contingency Buffer | milestone | 0d | 2008-09-10 A | 2008-09-10 A | 102 | 100% | 2008-08-21 | 2008-09-04 | 10d | Developer - 1; Developer - 2; Developer - 3 |  |  |  | 12,000 |  |
